# Special Event Plan

Schedule from MS Project, 1998-01-02 to 1998-04-30.

## Calendars

- Standard: Mon-Fri 08:00-12:00, 13:00-17:00; Sat-Sun off.

## Schedule

| ID | WBS | Task | Duration | Start | Finish | Predecessors | Total slack |
| --- | --- | --- | --- | --- | --- | --- | --- |
| 1 | 1 | **Special Event** | 85d | 1998-01-02 | 1998-04-30 |  | 0d |
| 2 | 1.1 | **Pre-planning** | 70d | 1998-01-02 | 1998-04-09 |  | 0d |
| 3 | 1.1.1 | **Initial planning meetings** | 1d | 1998-01-02 | 1998-01-02 |  | 0d |
| 4 | 1.1.1.1 | Determine budget | 1d | 1998-01-02 | 1998-01-02 |  | 0d |
| 5 | 1.1.1.2 | Invitation list | 1d | 1998-01-02 | 1998-01-02 |  | 15d |
| 6 | 1.1.2 | **Selection** | 15d | 1998-01-05 | 1998-01-23 | 4 | 0d |
| 7 | 1.1.2.1 | Theme | 2d | 1998-01-05 | 1998-01-06 |  | 0d |
| 8 | 1.1.2.2 | Date | 3d | 1998-01-07 | 1998-01-09 | 7 | 0d |
| 9 | 1.1.2.3 | Site | 1w | 1998-01-12 | 1998-01-16 | 8 | 0d |
| 10 | 1.1.2.4 | Costumes | 1w | 1998-01-19 | 1998-01-23 | 9 | 0d |
| 11 | 1.1.3 | **Hire** | 21d | 1998-01-26 | 1998-02-23 | 5, 10 | 0d |
| 12 | 1.1.3.1 | Caterer | 2d | 1998-01-26 | 1998-01-27 |  | 0d |
| 13 | 1.1.3.2 | Entertainment | 9d | 1998-01-28 | 1998-02-09 | 12 | 0d |
| 14 | 1.1.3.3 | Keynote speaker | 2w | 1998-02-10 | 1998-02-23 | 13 | 0d |
| 15 | 1.1.4 | **Public relations** | 11d | 1998-02-24 | 1998-03-10 | 6, 14 | 0d |
| 16 | 1.1.4.1 | Alert community | 2w | 1998-02-24 | 1998-03-09 |  | 0d |
| 17 | 1.1.4.2 | Press release | 1d | 1998-03-10 | 1998-03-10 | 16 | 0d |
| 18 | 1.1.5 | **Rent Equipment** | 5d | 1998-03-11 | 1998-03-17 | 15 | 0d |
| 19 | 1.1.5.1 | Rent tents | 2d | 1998-03-11 | 1998-03-12 |  | 0d |
| 20 | 1.1.5.2 | Rent audiovisual equipment | 2d | 1998-03-13 | 1998-03-16 | 19 | 0d |
| 21 | 1.1.5.3 | Rent tables and chairs | 1d | 1998-03-17 | 1998-03-17 | 20 | 0d |
| 22 | 1.1.6 | **Meet with Caterer** | 2d | 1998-03-18 | 1998-03-19 | 18 | 0d |
| 23 | 1.1.6.1 | Menu selection | 1d | 1998-03-18 | 1998-03-18 |  | 0d |
| 24 | 1.1.6.2 | Drink selection | 1d | 1998-03-19 | 1998-03-19 | 23 | 0d |

| ID | WBS | Task | Type | Duration | Start | Finish | Predecessors | Total slack |
| --- | --- | --- | --- | --- | --- | --- | --- | --- |
| 25 | 1.1.7 | **Hire Personnel** |  | 5d | 1998-03-20 | 1998-03-26 | 22 | 0d |
| 26 | 1.1.7.1 | Bartenders |  | 1d | 1998-03-20 | 1998-03-20 |  | 0d |
| 27 | 1.1.7.2 | Security |  | 2d | 1998-03-23 | 1998-03-24 | 26 | 0d |
| 28 | 1.1.7.3 | Photographer |  | 1d | 1998-03-25 | 1998-03-25 | 27 | 0d |
| 29 | 1.1.7.4 | Cleanup crew |  | 1d | 1998-03-26 | 1998-03-26 | 28 | 0d |
| 30 | 1.1.8 | **Arrangements** |  | 10d | 1998-03-27 | 1998-04-09 | 25 | 0d |
| 31 | 1.1.8.1 | Transportation for speaker |  | 1d | 1998-03-27 | 1998-03-27 |  | 0d |
| 32 | 1.1.8.2 | Event transportation |  | 3d | 1998-03-30 | 1998-04-01 | 31 | 0d |
| 33 | 1.1.8.3 | Flowers |  | 4d | 1998-04-02 | 1998-04-07 | 32 | 0d |
| 34 | 1.1.8.4 | Table decorations |  | 1d | 1998-04-08 | 1998-04-08 | 33 | 0d |
| 35 | 1.1.8.5 | Lighting |  | 1d | 1998-04-09 | 1998-04-09 | 34 | 0d |
| 36 | 1.2 | **Event Preparation** |  | 6d | 1998-04-10 | 1998-04-17 | 2 | 0d |
| 37 | 1.2.1 | Buy room decorations |  | 1d | 1998-04-10 | 1998-04-10 |  | 0d |
| 38 | 1.2.2 | Buy party favors |  | 1d | 1998-04-13 | 1998-04-13 | 37 | 0d |
| 39 | 1.2.3 | Setup equipment for event |  | 2d | 1998-04-14 | 1998-04-15 | 38 | 0d |
| 40 | 1.2.4 | Decorate |  | 2d | 1998-04-16 | 1998-04-17 | 39 | 0d |
| 41 | 1.2.5 | Special Event | milestone | 0d | 1998-04-17 | 1998-04-17 | 40 | 0d |
| 42 | 1.3 | **Event Wrap-up** |  | 9d | 1998-04-20 | 1998-04-30 | 36 | 0d |
| 43 | 1.3.1 | Cleanup |  | 2d | 1998-04-20 | 1998-04-21 |  | 0d |
| 44 | 1.3.2 | Pay bills |  | 4d | 1998-04-22 | 1998-04-27 | 43 | 0d |
| 45 | 1.3.3 | Write thank you letters |  | 2d | 1998-04-28 | 1998-04-29 | 44 | 0d |
| 46 | 1.3.4 | Write event summary |  | 1d | 1998-04-30 | 1998-04-30 | 45 | 0d |
| 47 | 1.3.5 | Vacation | milestone | 0d | 1998-04-30 | 1998-04-30 | 46 | 0d |
