# Renovation Plan

Schedule from MS Project, 1998-01-02 to 1998-04-16.

## Calendars

- Standard: Mon-Fri 08:00-12:00, 13:00-17:00; Sat-Sun off.

## Resources

| Resource |
| --- |
| Architect |
| Richard |
| Richard's Secretary |
| Mover |
| Electrician |
| Plumber |
| Telecom. Engineer |
| Inspector |
| Construction Worker |
| Interior Designer |
| AC Installer |
| Computer Store Installer |

## Schedule

| ID | WBS | Task | Type | Duration | Start | Finish | Predecessors | Total slack | Free slack | Resources | Work |
| --- | --- | --- | --- | --- | --- | --- | --- | --- | --- | --- | --- |
| 1 | 1 | **Design** |  | 42.25d | 1998-01-02 08:00 | 1998-03-03 10:00 |  | 0d |  |  | 284.8h |
| 2 | 1.1 | Determine best 5 potential architects |  | 1w | 1998-01-02 08:00 | 1998-01-08 17:00 |  | 0d |  | Richard | 40h |
| 3 | 1.2 | **Interview architects** |  | 1.25d | 1998-01-09 08:00 | 1998-01-12 10:00 |  | 0d |  |  | 10h |
| 4 | 1.2.1 | Architect 1 |  | 2h | 1998-01-09 08:00 | 1998-01-09 10:00 | 2 | 0d |  | Architect | 2h |
| 5 | 1.2.2 | Architect 2 |  | 2h | 1998-01-09 10:00 | 1998-01-09 12:00 | 4 | 0d |  | Architect | 2h |
| 6 | 1.2.3 | Architect 3 |  | 2h | 1998-01-09 13:00 | 1998-01-09 15:00 | 5 | 0d |  | Architect | 2h |
| 7 | 1.2.4 | Architect 4 |  | 2h | 1998-01-09 15:00 | 1998-01-09 17:00 | 6 | 0d |  | Architect | 2h |
| 8 | 1.2.5 | Architect 5 |  | 2h | 1998-01-12 08:00 | 1998-01-12 10:00 | 7 | 0d |  | Architect | 2h |
| 9 | 1.3 | Select architect |  | 1d | 1998-01-12 10:00 | 1998-01-13 10:00 | 8 | 0d |  | Richard | 8h |
| 10 | 1.4 | Prepare 1st draft plan |  | 3w | 1998-01-13 10:00 | 1998-02-03 10:00 | 9 | 0d |  | Architect | 120h |
| 11 | 1.5 | Review draft |  | 1w | 1998-02-03 10:00 | 1998-02-10 10:00 | 10 | 25.38d | 0d | Richard [12%] | 4.8h |
| 12 | 1.6 | Revise draft |  | 2w | 1998-02-10 10:00 | 1998-02-24 10:00 | 11 | 25.38d | 0d | Architect | 80h |
| 13 | 1.7 | Receive final plan | milestone | 0d | 1998-02-24 10:00 | 1998-02-24 10:00 | 12 | 25.38d | 0d | Architect; Richard |  |
| 14 | 1.8 | Design telecommunications plan |  | 1w | 1998-02-24 10:00 | 1998-03-03 10:00 | 13 | 25.38d | 0d | Telecom. Engineer [25%]; Richard [10%] | 14h |
| 15 | 1.9 | Obtain construction permit |  | 4w | 1998-02-03 10:00 | 1998-03-03 10:00 | 10 | 0d |  | Architect [5%] | 8h |
| 16 | 2 | **Pre-Renovation** |  | 8.5d | 1998-03-03 10:00 | 1998-03-13 15:00 |  | 1.5d |  |  | 72h |
| 17 | 2.1 | Call moving services for quotes |  | 1w | 1998-03-03 10:00 | 1998-03-10 10:00 | 15 | 1.5d | 0d | Richard's Secretary | 40h |
| 18 | 2.2 | Hire movers | milestone | 0d | 1998-03-10 10:00 | 1998-03-10 10:00 | 17 | 1.5d | 0d | Richard's Secretary |  |
| 19 | 2.3 | Pack rooms |  | 1d | 1998-03-12 10:00 | 1998-03-13 10:00 | 18FS+2d | 1.5d | 0d | Mover [300%] | 24h |
| 20 | 2.4 | Remove boxes to storage |  | 0.5d | 1998-03-13 10:00 | 1998-03-13 15:00 | 19 | 1.5d | 0d | Mover [200%] | 8h |
| 21 | 3 | **Renovation** |  | 26d | 1998-03-03 10:00 | 1998-04-08 10:00 |  | 6.5d |  |  | 496h |
| 22 | 3.1 | **Construction** |  | 17d | 1998-03-13 15:00 | 1998-04-07 15:00 |  | 1.5d |  |  | 268h |
| 23 | 3.1.1 | Strip walls |  | 2d | 1998-03-13 15:00 | 1998-03-17 15:00 | 20 | 1.5d | 0d | Construction Worker [300%] | 48h |
| 24 | 3.1.2 | Remove existing wall |  | 1.5d | 1998-03-17 15:00 | 1998-03-19 10:00 | 23 | 1.5d | 0d | Construction Worker [200%] | 24h |
| 25 | 3.1.3 | Frame new walls |  | 2d | 1998-03-19 10:00 | 1998-03-23 10:00 | 24 | 1.5d | 0d | Construction Worker [200%] | 32h |
| 26 | 3.1.4 | Construction Inspection |  | 0.5d | 1998-03-23 10:00 | 1998-03-23 15:00 | 25 | 1.5d | 0d | Inspector; Richard | 8h |
| 27 | 3.1.5 | Put up dry wall |  | 2d | 1998-03-23 15:00 | 1998-03-25 15:00 | 26 | 1.5d | 0d | Construction Worker [300%] | 48h |
| 28 | 3.1.6 | Plaster |  | 1d | 1998-03-25 15:00 | 1998-03-26 15:00 | 27 | 1.5d | 0d | Construction Worker [200%] | 16h |
| 29 | 3.1.7 | Sand |  | 0.5d | 1998-03-26 15:00 | 1998-03-27 10:00 | 28 | 1.5d | 0d | Construction Worker | 4h |
| 30 | 3.1.8 | Paint (1st coat) |  | 2d | 1998-03-27 10:00 | 1998-03-31 10:00 | 29 | 1.5d | 0d | Construction Worker | 16h |
| 31 | 3.1.9 | Paint (2nd coat) |  | 2d | 1998-03-31 10:00 | 1998-04-02 10:00 | 30 | 1.5d | 0d | Construction Worker | 16h |
| 32 | 3.1.10 | Add skirting boards and trim |  | 0.5d | 1998-04-02 10:00 | 1998-04-02 15:00 | 31 | 2.5d | 1d | Construction Worker [200%] | 8h |
| 33 | 3.1.11 | Install new cabinets |  | 0.5d | 1998-04-02 10:00 | 1998-04-02 15:00 | 31 | 1.5d | 0d | Construction Worker [200%] | 8h |
| 34 | 3.1.12 | Paint cabinets |  | 1d | 1998-04-02 15:00 | 1998-04-03 15:00 | 33 | 1.5d | 0d | Construction Worker | 8h |
| 35 | 3.1.13 | Lay new flooring |  | 1d | 1998-04-03 15:00 | 1998-04-06 15:00 | 32, 34 | 1.5d | 0d | Construction Worker [200%] | 16h |
| 36 | 3.1.14 | Install appliances |  | 1d | 1998-04-06 15:00 | 1998-04-07 15:00 | 35, 49, 54SS | 1.5d | 0d | Construction Worker [200%] | 16h |

| ID | WBS | Task | Duration | Start | Finish | Predecessors | Total slack | Free slack | Resources | Work |
| --- | --- | --- | --- | --- | --- | --- | --- | --- | --- | --- |
| 37 | 3.2 | **Air Conditioning** | 14.5d | 1998-03-13 15:00 | 1998-04-03 10:00 |  | 9.25d |  |  | 84h |
| 38 | 3.2.1 | Install ducting | 1.5d | 1998-03-23 10:00 | 1998-03-24 15:00 | 25 | 9.5d | 0d | AC Installer [300%] | 36h |
| 39 | 3.2.2 | Install vents | 1d | 1998-03-24 15:00 | 1998-03-25 15:00 | 25, 38 | 9.5d | 5.5d | AC Installer [300%] | 24h |
| 40 | 3.2.3 | Install main unit | 1d | 1998-03-13 15:00 | 1998-03-16 15:00 | 23SS | 22.75d | 9.5d | AC Installer [200%] | 16h |
| 41 | 3.2.4 | Install thermometers and controls | 1d | 1998-04-02 10:00 | 1998-04-03 10:00 | 31, 39 | 4d | 2.5d | AC Installer | 8h |
| 42 | 3.3 | **Electrical** | 8.5d | 1998-03-23 10:00 | 1998-04-02 15:00 |  | 6.75d |  |  | 56h |
| 43 | 3.3.1 | Install new fuse box | 0.5d | 1998-03-23 10:00 | 1998-03-23 15:00 | 25 | 6.75d | 0d | Electrician | 4h |
| 44 | 3.3.2 | Upgrade wiring | 3d | 1998-03-23 15:00 | 1998-03-26 15:00 | 43 | 6.75d | 0d | Electrician | 24h |
| 45 | 3.3.3 | Install new switches and outlets | 1d | 1998-03-26 15:00 | 1998-03-27 15:00 | 25, 44 | 6.75d | 0d | Electrician | 8h |
| 46 | 3.3.4 | Electrical Inspection | 0.5d | 1998-03-27 15:00 | 1998-03-30 10:00 | 45 | 6.75d | 0d | Electrician; Inspector; Richard | 12h |
| 47 | 3.3.5 | Connect air conditioning | 2h | 1998-03-30 10:00 | 1998-03-30 12:00 | 40, 44, 46 | 13.25d |  | Electrician | 2h |
| 48 | 3.3.6 | Install smoke detectors | 0.5d | 1998-04-02 10:00 | 1998-04-02 15:00 | 31, 44, 46 | 10d |  | Electrician | 4h |
| 49 | 3.3.7 | Attach face plates | 2h | 1998-04-02 10:00 | 1998-04-02 12:00 | 31, 46 | 3.75d | 2.25d | Electrician | 2h |
| 50 | 3.4 | **Plumbing** | 11.5d | 1998-03-19 10:00 | 1998-04-03 15:00 |  | 8.5d |  |  | 62h |
| 51 | 3.4.1 | Install pipes | 5d | 1998-03-19 10:00 | 1998-03-26 10:00 | 24 | 8.5d | 0d | Plumber | 40h |
| 52 | 3.4.2 | Plumbing Inspection | 0.5d | 1998-03-26 10:00 | 1998-03-26 15:00 | 51 | 8.5d | 0d | Inspector; Richard; Plumber | 12h |
| 53 | 3.4.3 | Install sink and faucets | 1d | 1998-04-02 15:00 | 1998-04-03 15:00 | 33, 52 | 9d |  | Plumber | 8h |
| 54 | 3.4.4 | Connect appliances | 2h | 1998-03-26 15:00 | 1998-03-26 17:00 | 52 | 8.5d | 7d | Plumber | 2h |
| 55 | 3.5 | **Telecommunications** | 22.62d | 1998-03-03 10:00 | 1998-04-02 16:00 |  | 9.88d |  |  | 18h |
| 56 | 3.5.1 | Install LAN backbone | 1d | 1998-03-23 10:00 | 1998-03-24 10:00 | 14, 25 | 11.38d | 7d | Telecom. Engineer | 8h |
| 57 | 3.5.2 | Order new phone lines | 1h | 1998-03-03 10:00 | 1998-03-03 11:00 | 14 | 32.38d |  | Richard's Secretary | 1h |
| 58 | 3.5.3 | Install phone lines and jacks | 0.5d | 1998-03-23 10:00 | 1998-03-23 15:00 | 25 | 17.5d | 14d | Telecom. Engineer | 4h |
| 59 | 3.5.4 | Install LAN cover plates | 1h | 1998-04-02 10:00 | 1998-04-02 11:00 | 31, 56 | 4.38d | 0d | Telecom. Engineer | 1h |
| 60 | 3.5.5 | LAN testing and acceptance | 0.5d | 1998-04-02 11:00 | 1998-04-02 16:00 | 59 | 4.38d | 2.88d | Telecom. Engineer | 4h |
| 61 | 3.6 | Final Inspection | 0.5d | 1998-04-07 15:00 | 1998-04-08 10:00 | 36, 41, 54, 60 | 1.5d | 0.75d | Inspector; Richard | 8h |

| ID | WBS | Task | Duration | Start | Finish | Predecessors | Total slack | Free slack | Resources | Work |
| --- | --- | --- | --- | --- | --- | --- | --- | --- | --- | --- |
| 62 | 4 | **Furnish** | 29.5d | 1998-03-03 10:00 | 1998-04-13 15:00 |  | 0d |  |  | 59h |
| 63 | 4.1 | Contract Interior designer | 0.5d | 1998-03-03 10:00 | 1998-03-03 15:00 | 15 | 0d |  | Richard | 4h |
| 64 | 4.2 | Select color scheme and furniture | 1d | 1998-03-10 15:00 | 1998-03-11 15:00 | 63FS+1w | 0d |  | Richard; Interior Designer | 16h |
| 65 | 4.3 | Order new furniture | 1d | 1998-03-11 15:00 | 1998-03-12 15:00 | 64 | 0d |  | Interior Designer | 8h |
| 66 | 4.4 | Order Blinds | 2h | 1998-03-11 15:00 | 1998-03-11 17:00 | 64 | 4.75d | 0d | Interior Designer | 2h |
| 67 | 4.5 | Install blinds | 1d | 1998-04-09 08:00 | 1998-04-09 17:00 | 61, 66FS+4w | 4.75d |  | Interior Designer | 8h |
| 68 | 4.6 | Furniture delivery | 1d | 1998-04-09 15:00 | 1998-04-10 15:00 | 61, 65FS+4w | 0d |  | Mover | 8h |
| 69 | 4.7 | **Accessory delivery and installation** | 7d | 1998-04-02 15:00 | 1998-04-13 15:00 |  | 3d |  |  | 13h |
| 70 | 4.7.1 | Lamps | 3h | 1998-04-02 15:00 | 1998-04-03 09:00 | 65FS+3w | 9.62d |  | Mover | 3h |
| 71 | 4.7.2 | Plants | 2h | 1998-04-10 15:00 | 1998-04-10 17:00 | 68 | 3.75d |  | Mover | 2h |
| 72 | 4.7.3 | Paintings | 1d | 1998-04-10 15:00 | 1998-04-13 15:00 | 68 | 3d |  | Mover | 8h |
| 73 | 5 | **Post-Renovation** | 4d | 1998-04-10 15:00 | 1998-04-16 15:00 |  | 0d |  |  | 88h |
| 74 | 5.1 | Retrieve boxes from storage | 1d | 1998-04-10 15:00 | 1998-04-13 15:00 | 68 | 0d |  | Mover [200%] | 16h |
| 75 | 5.2 | Unpack | 3d | 1998-04-13 15:00 | 1998-04-16 15:00 | 74 | 0d |  | Richard; Richard's Secretary | 48h |
| 76 | 5.3 | Install phones/fax machine | 0.5d | 1998-04-10 15:00 | 1998-04-13 10:00 | 58, 68 | 3.5d |  | Telecom. Engineer | 4h |
| 77 | 5.4 | Install PCs | 2d | 1998-04-10 15:00 | 1998-04-14 15:00 | 60, 68 | 2d |  | Computer Store Installer | 16h |
| 78 | 5.5 | Install printer | 0.5d | 1998-04-10 15:00 | 1998-04-13 10:00 | 60, 68 | 3.5d |  | Computer Store Installer | 4h |
